Schedule from GanttProject, 2015-12-14 to 2016-03-18.

## Calendars

- Project calendar: Mon-Fri working; Sat-Sun off.

## Resources

| Resource |
| --- |
| Amir Shehata |
| Olaf Webber |

## Schedule

| ID | WBS | Task | Duration | Start | Finish | Predecessors | Resources |
| --- | --- | --- | --- | --- | --- | --- | --- |
| 1 | 1 | Split lnet_ni | 5d | 2015-12-14 | 2015-12-18 |  | Amir Shehata |
| 2 | 2 | Vacation | 10d | 2015-12-21 | 2016-01-01 |  | Amir Shehata; Olaf Webber |
| 3 | 3 | Split peer | 5d | 2016-01-04 | 2016-01-08 | 2 | Amir Shehata |
| 4 | 4 | **lnetct NI work** | 3d | 2016-01-11 | 2016-01-13 | 3 | Amir Shehata |
| 5 | 4.1 | Config NI | 3d | 2016-01-11 | 2016-01-13 |  |  |
| 6 | 4.2 | Del NI | 3d | 2016-01-11 | 2016-01-13 |  |  |
| 7 | 4.3 | Show NI | 3d | 2016-01-11 | 2016-01-13 |  |  |
| 8 | 5 | **DLC NI work** | 3d | 2016-01-14 | 2016-01-18 | 4 | Amir Shehata |
| 9 | 5.1 | Config NI | 3d | 2016-01-14 | 2016-01-18 |  |  |
| 10 | 5.2 | Del NI | 3d | 2016-01-14 | 2016-01-18 |  |  |
| 11 | 5.3 | Show NI | 3d | 2016-01-14 | 2016-01-18 |  |  |
| 12 | 6 | **LNet Config Handling NI** | 4d | 2016-01-19 | 2016-01-22 | 8 | Amir Shehata |
| 13 | 6.1 | Copy_Config NI | 4d | 2016-01-19 | 2016-01-22 |  |  |
| 14 | 6.2 | Copy_Del NI | 4d | 2016-01-19 | 2016-01-22 |  |  |
| 15 | 6.3 | Copy_Show NI | 4d | 2016-01-19 | 2016-01-22 |  |  |
| 16 | 7 | **lnetct Peer Work** | 5d | 2016-01-25 | 2016-01-29 | 12 | Amir Shehata |
| 17 | 7.1 | Config peer | 5d | 2016-01-25 | 2016-01-29 |  |  |
| 18 | 7.2 | Del peer | 5d | 2016-01-25 | 2016-01-29 |  |  |
| 19 | 7.3 | Show peer | 5d | 2016-01-25 | 2016-01-29 |  |  |
| 20 | 8 | **DLC Peer work** | 5d | 2016-02-01 | 2016-02-05 | 16 | Amir Shehata |
| 21 | 8.1 | Config Peer | 5d | 2016-02-01 | 2016-02-05 |  |  |
| 22 | 8.2 | Del Peer | 5d | 2016-02-01 | 2016-02-05 |  |  |
| 23 | 8.3 | Show Peer | 5d | 2016-02-01 | 2016-02-05 |  |  |
| 24 | 9 | **LNet Config Handling Peer** | 5d | 2016-02-08 | 2016-02-12 | 20 | Amir Shehata |
| 25 | 9.1 | Copy_Config Peer | 5d | 2016-02-08 | 2016-02-12 |  |  |
| 26 | 9.2 | Copy_Del Peer | 5d | 2016-02-08 | 2016-02-12 |  |  |
| 27 | 9.3 | Copy_Show Peer | 5d | 2016-02-08 | 2016-02-12 |  |  |
| 28 | 10 | Selection Algorithm | 5d | 2016-02-15 | 2016-02-19 | 24 | Amir Shehata |

| ID | WBS | Task | Duration | Start | Finish | Predecessors | Resources |
| --- | --- | --- | --- | --- | --- | --- | --- |
| 29 | 11 | **lnetctl UDSP work** | 5d | 2016-02-22 | 2016-02-26 | 28 | Amir Shehata |
| 30 | 11.1 | Config UDSP | 5d | 2016-02-22 | 2016-02-26 |  |  |
| 31 | 11.2 | Del UDSP | 5d | 2016-02-22 | 2016-02-26 |  |  |
| 32 | 11.3 | Show UDSP | 5d | 2016-02-22 | 2016-02-26 |  |  |
| 33 | 12 | **DLC UDSP work** | 5d | 2016-02-29 | 2016-03-04 | 29 | Amir Shehata |
| 34 | 12.1 | Config UDSP | 5d | 2016-02-29 | 2016-03-04 |  |  |
| 35 | 12.2 | Del UDSP | 5d | 2016-02-29 | 2016-03-04 |  |  |
| 36 | 12.3 | Show UDSP | 5d | 2016-02-29 | 2016-03-04 |  |  |
| 37 | 13 | **LNet UDSP Config Handling** | 5d | 2016-03-07 | 2016-03-11 | 33 | Amir Shehata |
| 38 | 13.1 | Config UDSP | 5d | 2016-03-07 | 2016-03-11 |  |  |
| 39 | 13.2 | Del UDSP | 5d | 2016-03-07 | 2016-03-11 |  |  |
| 40 | 13.3 | Show UDSP | 5d | 2016-03-07 | 2016-03-11 |  |  |
| 41 | 14 | Applying UDSP | 5d | 2016-03-14 | 2016-03-18 | 37 | Amir Shehata |
| 42 | 15 | Handling send failure | 5d | 2016-02-22 | 2016-02-26 | 28 | Olaf Webber |
| 43 | 16 | Dynamic Discovery Ping | 15d | 2016-01-11 | 2016-01-29 | 3 | Olaf Webber |
| 44 | 17 | Dynamic Discovery Push | 20d | 2016-02-01 | 2016-02-26 | 43 | Olaf Webber |
| 45 | 18 | Health Monitoring - Part 1 | 5d | 2015-12-14 | 2015-12-18 |  | Olaf Webber |
| 46 | 19 | Health Monitoring - Part 2 | 5d | 2016-02-29 | 2016-03-04 | 44 | Olaf Webber |
